# Current kiLO Project Schedule

Schedule from MS Project, 2006-01-09 to 2006-05-26, 4 hours a day, A marks actual dates.
College

## Calendars

- Standard: Mon-Fri 08:00-12:00, 13:00-17:00; Sat-Sun off. Exceptions (off unless hours are given): 2006-01-09 to 2006-01-13 08:00-12:00, 2006-01-14 to 2006-01-15, 2006-01-16 to 2006-01-20 08:00-12:00, 2006-01-21 to 2006-01-22, 2006-01-23 to 2006-01-27 08:00-12:00, 2006-01-28 to 2006-01-29, 2006-01-30 to 2006-02-03 08:00-12:00, 2006-02-04 to 2006-02-05, 2006-02-06 to 2006-02-10 08:00-12:00, 2006-02-11, 2006-02-12 08:00-12:00, 13:00-17:00, 2006-02-13 to 2006-02-17 08:00-12:00, 2006-02-18 to 2006-02-19, 2006-02-20 to 2006-02-24 08:00-12:00, 2006-02-25 to 2006-02-26, 2006-02-27 to 2006-03-03 08:00-12:00, 2006-03-04 to 2006-03-05, 2006-03-06 to 2006-03-10 08:00-12:00, 2006-03-11 to 2006-03-12, 2006-03-13 to 2006-03-17 08:00-12:00, 2006-03-18 to 2006-03-19, 2006-03-20 to 2006-03-24 08:00-12:00, 2006-03-25 to 2006-03-26, 2006-03-27 to 2006-03-31 08:00-12:00, 2006-04-01 to 2006-04-02, 2006-04-03 to 2006-04-07 08:00-12:00, 2006-04-08 to 2006-04-09, 2006-04-10 to 2006-04-14 08:00-12:00, 2006-04-15 to 2006-04-16, 2006-04-17 to 2006-04-21 08:00-12:00, 2006-04-22 to 2006-04-23, 2006-04-24 to 2006-04-28 08:00-12:00, 2006-04-29 to 2006-04-30, 2006-05-01 to 2006-05-05 08:00-12:00, 2006-05-06 to 2006-05-07, 2006-05-08 to 2006-05-12 08:00-12:00, 2006-05-13 to 2006-05-14, 2006-05-15 to 2006-05-19 08:00-12:00, 2006-05-20 to 2006-05-21, 2006-05-22 to 2006-05-26 08:00-12:00.

## Resources

| Resource |
| --- |
| Tom |
| Lora |
| All |
| Amanda |
| Jack |
| Shawn |
| Nick |

## Schedule

| ID | Task | Type | Duration | Start | Finish | Predecessors | Complete | Remaining | Total slack | Free slack | Constraint | Deadline | Resources | Work | Actual work |
| --- | --- | --- | --- | --- | --- | --- | --- | --- | --- | --- | --- | --- | --- | --- | --- |
| 1 | Detail Requirements |  | 2d? | 2006-01-09 A | 2006-01-10 A |  | 100% |  |  |  |  |  | Tom; Lora | 16h | 16h |
| 2 | Review Requirements |  | 2d? | 2006-01-16 A | 2006-01-17 A | 1 | 100% |  |  |  | start no earlier than 2006-01-16 |  | All | 8h | 8h |
| 3 | Detail Requirements further |  | 2.1d? | 2006-01-24 A | 2006-02-07 A |  | 100% |  |  |  | start no earlier than 2006-01-24 |  | All | 8.4h | 8.4h |
| 4 | Review Requirements Detail |  | 2d? | 2006-01-26 A | 2006-02-07 A | 3 | 100% |  |  |  | start no earlier than 2006-01-26 |  | All | 8h | 8h |
| 5 | Determine process for change management |  | 2h? | 2006-01-24 A | 2006-01-24 A |  | 100% |  |  |  | start no earlier than 2006-01-24 |  | All | 2h | 2h |
| 6 | Determine metrics |  | 5h? | 2006-01-20 A | 2006-01-23 A |  | 100% |  |  |  | start no earlier than 2006-01-20 |  | Amanda; All | 10h | 10h |
| 7 | Priortize Requirements |  | 2h? | 2006-01-18 A | 2006-01-18 A | 2 | 100% |  |  |  | start no earlier than 2006-01-17 |  | All; Jack | 4h | 4h |
| 8 | Update Risks Based on Requirements |  | 2h? | 2006-01-24 A | 2006-01-24 A | 7 | 100% |  |  |  | start no earlier than 2006-01-24 |  | Amanda | 2h | 2h |
| 9 | Create/gather Testing templates |  | 4h? | 2006-01-24 A | 2006-01-24 A |  | 100% |  |  |  | start no earlier than 2006-01-24 |  | Amanda | 4h | 4h |
| 10 | Create Acceptance Test Plan |  | 6h? | 2006-01-30 A | 2006-01-31 A | 4 | 100% |  |  |  | start no earlier than 2006-01-30 |  | Shawn | 6h | 6h |
| 11 | Review Acceptance Test Plan |  | 3h? | 2006-01-31 A | 2006-02-01 A | 10 | 100% |  |  |  |  |  | All | 3h | 3h |
| 12 | High-level System Design |  | 4h? | 2006-01-18 A | 2006-01-19 A | 7 | 100% |  |  |  | start no earlier than 2006-01-18 |  | Nick | 4h | 4h |
| 13 | Review High-level System Design |  | 1h? | 2006-01-26 A | 2006-01-26 A | 12 | 100% |  |  |  | start no earlier than 2006-01-26 |  | All | 1h | 1h |
| 14 | Create detailed user use cases |  | 4h? | 2006-01-31 A | 2006-01-31 A |  | 100% |  |  |  | start no earlier than 2006-01-31 |  |  |  |  |
| 15 | Review detailed user use cases |  | 2h | 2006-02-02 A | 2006-02-02 A | 14 | 100% |  |  |  | start no earlier than 2006-02-02 |  |  |  |  |
| 16 | Create System Test Plan |  | 9h? | 2006-02-06 A | 2006-03-10 A | 9 | 100% |  |  |  | start no earlier than 2006-02-06 |  | Shawn | 9h | 9h |
| 17 | Review System Test Plan |  | 3h? | 2006-03-13 A | 2006-03-20 A | 16 | 100% |  |  |  | start no earlier than 2006-03-13 |  | All | 3h | 3h |
| 18 | Create Detailed Architecture/Application Design |  | 11.05h? | 2006-01-26 A | 2006-02-17 A | 13 | 100% |  |  |  |  |  | Nick; Tom | 17h | 17h |
| 19 | Review Detailed Architecture/Application Design |  | 4h? | 2006-02-17 A | 2006-02-20 A | 18 | 100% |  |  |  |  |  | All | 4h | 4h |
| 20 | Create Integration Test Plan |  | 7h? | 2006-03-10 A | 2006-03-13 A | 9, 24 | 100% |  |  |  | start no earlier than 2006-03-10 |  | Shawn | 7h | 7h |
| 21 | Review Integration Test Plan |  | 2h? | 2006-03-13 A | 2006-03-17 A | 20 | 100% |  |  |  | start no earlier than 2006-03-13 |  | All | 2h | 2h |
| 22 | Detailed Component Design |  | 40h? | 2006-02-20 A | 2006-03-06 A | 19 | 100% |  |  |  |  |  | Nick; Tom | 80h | 80h |
| 23 | MapPoint.NET Proof of concept on the server | milestone | 0h | 2006-02-17 A | 2006-02-17 A |  | 100% |  |  |  | start no earlier than 2006-02-17 |  |  |  |  |
| 24 | Reivew Detailed Component Design |  | 6h? | 2006-03-06 A | 2006-03-08 A | 22 | 100% |  |  |  |  |  | All | 6h | 6h |
| 25 | Create Unit Test Plan |  | 12h? | 2006-03-10 A | 2006-03-20 A | 24, 9 | 100% |  |  |  | start no earlier than 2006-03-10 |  | Shawn | 12h | 12h |
| 26 | Review Unit Test Plan |  | 3h? | 2006-03-13 A | 2006-03-21 A | 25 | 100% |  |  |  |  |  | All | 3h | 3h |
| 27 | Create and review all Test Plans | milestone | 0h | 2006-03-20 A | 2006-03-20 A | 11, 17, 21, 26 | 100% |  |  |  |  |  |  |  |  |
| 28 | UI Paper Prototype |  | 16h? | 2006-01-31 A | 2006-02-03 A |  | 100% |  |  |  | start no earlier than 2006-01-31 |  | Lora; Amanda | 32h | 32h |
| 29 | Sign off on UI Prototype | milestone | 0h | 2006-02-14 A | 2006-02-14 A | 28 | 100% |  |  |  | start no earlier than 2006-02-14 |  | Jack; All |  |  |
| 30 | Proof of concept with MapPoint.NET |  | 5h? | 2006-01-09 A | 2006-01-10 A |  | 100% |  |  |  |  |  | Shawn | 5h | 5h |
| 31 | Research/Set-up Nokia IDE |  | 25h? | 2006-01-10 A | 2006-01-18 A | 30 | 100% |  |  |  |  |  | All | 25h | 25h |
| 32 | Nokia IDE Connects to the Internet | milestone | 0h | 2006-01-18 A | 2006-01-18 A | 31 | 100% |  |  |  |  |  |  |  |  |
| 33 | Proven interaction between the IDE and GPS Hardware |  | 4h? | 2006-02-01 A | 2006-02-01 A | 32 | 100% |  |  |  | start no earlier than 2006-02-01 |  | Nick; Tom; Shawn | 11.2h | 11.2h |
| 34 | JSR-179 (Subclassing and Server) implementation |  | 6h? | 2006-03-20 A | 2006-03-21 A | 24, 30, 31, 33 | 100% |  |  |  | start no earlier than 2006-03-20 |  | Nick | 6h | 6h |
| 35 | Model Component |  | 3h? | 2006-03-24 A | 2006-03-28 A | 34 | 100% |  |  |  | start no earlier than 2006-03-24 |  | Amanda | 3h | 3h |
| 36 | Test Model Component |  | 2h? | 2006-03-28 A | 2006-03-28 A | 35 | 100% |  |  |  |  |  | Amanda | 2h | 2h |
| 37 | Client UI Component |  | 20h? | 2006-03-28 A | 2006-05-02 | 36 | 90% | 2h? | 0d |  |  |  | Lora | 20h | 18h |
| 38 | Unit test Client UI Component |  | 6h? | 2006-04-18 A | 2006-05-03 | 37 | 50% | 3h? | 0d |  |  |  | Lora | 6h | 3h |
| 39 | Request Component |  | 6h? | 2006-04-04 A | 2006-04-05 A | 36, 44 | 100% |  |  |  | start no earlier than 2006-04-04 |  | Shawn | 6h | 6h |
| 40 | Unit Test Request Component |  | 5h? | 2006-04-05 A | 2006-04-06 A | 39 | 100% |  |  |  |  |  | Shawn | 5h | 5h |
| 41 | Mediator |  | 12h? | 2006-04-11 A | 2006-04-13 A |  | 100% |  |  |  | start no earlier than 2006-04-11 |  | Shawn | 12h | 12h |
| 42 | Unit test Mediator |  | 7h? | 2006-04-14 A | 2006-04-17 A | 41 | 100% |  |  |  |  |  | Shawn | 7h | 7h |
| 43 | XML Component |  | 5h? | 2006-03-28 A | 2006-03-29 A | 36 | 100% |  |  |  |  |  | Shawn | 5h | 5h |
| 44 | Unit Test XML Component |  | 2h? | 2006-03-29 A | 2006-03-30 A | 43 | 100% |  |  |  |  |  | Shawn | 2h | 2h |
| 45 | Servlet Component |  | 5h? | 2006-04-03 A | 2006-04-04 A | 48 | 100% |  |  |  |  |  | Nick | 5h | 5h |
| 46 | Unit Test Servlet Component |  | 3h? | 2006-04-04 A | 2006-04-05 A | 45 | 100% |  |  |  |  |  | Nick | 3h | 3h |
| 47 | Servlet State Component |  | 15h? | 2006-03-27 A | 2006-03-30 A | 34 | 100% |  |  |  | start no earlier than 2006-03-27 |  | Tom; Nick | 30h | 30h |
| 48 | Unit Test Servlet State Component |  | 7h? | 2006-03-30 A | 2006-04-03 A | 47 | 100% |  |  |  |  |  | Tom; Nick | 14h | 14h |
| 49 | MapPoint Component |  | 12h? | 2006-03-27 A | 2006-05-01 | 34 | 95% | 0.6h? | 2.04d | 0d | start no earlier than 2006-03-27 |  | Tom | 12h | 11.4h |
| 50 | Unit Test mapPoint Component |  | 5h? | 2006-04-11 A | 2006-05-02 | 49 | 95% | 0.25h? | 1.19d | 0d |  |  | Tom | 5h | 4.75h |
| 51 | Response Component |  | 7h? | 2006-03-28 A | 2006-03-30 A | 36 | 100% |  |  |  |  |  | Nick | 7h | 7h |
| 52 | Unit test Response Component |  | 4h? | 2006-03-30 A | 2006-04-03 A | 26, 51 | 100% |  |  |  |  |  | Nick | 4h | 4h |
| 53 | Bug Fixing (after Unit testing) |  | 18h? | 2006-04-24 A | 2006-05-04 | 55 | 73% | 4.8h? | 0d |  |  |  | Tom; Lora; Amanda; Shawn; Nick | 90h | 66h |
| 54 | Construct Components and conduct Unit tests | milestone | 0h | 2006-05-04 | 2006-05-04 | 53 |  |  | 16d |  |  |  |  |  |  |
| 55 | Integrate each component into system |  | 10h? | 2006-04-20 A | 2006-05-03 | 34, 36, 38, 42, 40, 44, 46, 48, 50, 52 | 90% | 1h? | 0d |  | start no earlier than 2006-04-17 |  | All | 10h | 9h |
| 56 | Integration Testing |  | 15h? | 2006-05-04 | 2006-05-10 | 55, 21, 53 |  |  | 0d |  |  |  | All | 15h |  |
| 57 | Bug Fixing (after integration testing) |  | 12h? | 2006-05-10 | 2006-05-15 | 56 |  |  | 0d |  |  |  | All | 12h |  |
| 58 | System test |  | 10h? | 2006-05-15 | 2006-05-17 | 17, 57 |  |  | 0d |  |  |  | Shawn | 10h |  |
| 59 | Bug Fixing (after System testing) |  | 10h? | 2006-05-17 | 2006-05-22 | 58 |  |  | 0d |  |  |  | All | 10h |  |
| 60 | Acceptance test |  | 7h? | 2006-05-22 | 2006-05-24 | 11, 59 |  |  | 0d |  |  |  | Jack | 7h |  |
| 61 | Bug Fixing (after Acceptance testing) |  | 10h? | 2006-05-24 | 2006-05-26 | 60 |  |  | 0d |  |  |  | All | 10h |  |
| 62 | Sign off on application | milestone | 0h | 2006-05-26 | 2006-05-26 | 61 |  |  | 0d |  |  |  |  |  |  |
| 63 | Put together first quarter presentation |  | 10h? | 2006-02-17 A | 2006-02-21 A |  | 100% |  |  |  | finish no earlier than 2006-02-21 | 2006-02-21 | Lora; All | 20h | 20h |
| 64 | Put together second quarter presentation |  | 20h | 2006-05-05 A | 2006-05-11 | 63 | 20% | 16h | 1.75d |  | start no earlier than 2006-05-05 | 2006-05-15 | Lora; All | 40h | 8h |
| 65 | Investigate SOAP and MapPoint.NET interaction |  | 7h? | 2006-01-24 A | 2006-02-08 A |  | 100% |  |  |  | start no earlier than 2006-01-24 |  | Shawn; Tom | 10h | 10h |
| 66 | Create Users Manual |  | 15h? | 2006-05-01 | 2006-05-04 |  |  |  | 13.25d |  | start no earlier than 2006-05-01 |  | Lora; Amanda | 30h |  |
| 67 | Determine process for compiliation |  | 2h? | 2006-01-26 A | 2006-01-26 A |  | 100% |  |  |  | start no earlier than 2006-01-26 |  | All | 2h | 2h |
| 68 | Compile metrics |  | 20h? | 2006-04-05 A | 2006-04-19 | 6 | 80% | 4h? | 27.2d |  | start no earlier than 2006-04-05 |  | Amanda; Lora | 40h | 32h |
| 69 | Create Technical Report |  | 20h? | 2006-03-20 A | 2006-04-20 |  | 70% | 6h? | 26.2d |  | start no earlier than 2006-03-20 |  | Amanda; Lora | 40h | 28h |
