# Current kiLO Project Schedule

Schedule from MS Project, 2006-01-09 to 2006-04-26, 4 hours a day, A marks actual dates.
College

## Calendars

- Standard: Mon-Fri 08:00-12:00, 13:00-17:00; Sat-Sun off. Exceptions (off unless hours are given): 2006-01-09 to 2006-01-13 08:00-12:00, 2006-01-14 to 2006-01-15, 2006-01-16 to 2006-01-20 08:00-12:00, 2006-01-21 to 2006-01-22, 2006-01-23 to 2006-01-27 08:00-12:00, 2006-01-28 to 2006-01-29, 2006-01-30 to 2006-02-03 08:00-12:00, 2006-02-04 to 2006-02-05, 2006-02-06 to 2006-02-10 08:00-12:00, 2006-02-11, 2006-02-12 08:00-12:00, 13:00-17:00, 2006-02-13 to 2006-02-17 08:00-12:00, 2006-02-18 to 2006-02-19, 2006-02-20 to 2006-02-24 08:00-12:00, 2006-02-25 to 2006-02-26, 2006-02-27 to 2006-03-03 08:00-12:00, 2006-03-04 to 2006-03-05, 2006-03-06 to 2006-03-10 08:00-12:00, 2006-03-11 to 2006-03-12, 2006-03-13 to 2006-03-17 08:00-12:00, 2006-03-18 to 2006-03-19, 2006-03-20 to 2006-03-24 08:00-12:00, 2006-03-25 to 2006-03-26, 2006-03-27 to 2006-03-31 08:00-12:00, 2006-04-01 to 2006-04-02, 2006-04-03 to 2006-04-07 08:00-12:00, 2006-04-08 to 2006-04-09, 2006-04-10 to 2006-04-14 08:00-12:00, 2006-04-15 to 2006-04-16, 2006-04-17 to 2006-04-21 08:00-12:00, 2006-04-22 to 2006-04-23, 2006-04-24 to 2006-04-28 08:00-12:00.

## Resources

| Resource |
| --- |
| Tom |
| Lora |
| All |
| Amanda |
| Jack |
| Shawn |
| Nick |

## Schedule

| ID | Task | Type | Duration | Start | Finish | Predecessors | Complete | Remaining | Total slack | Free slack | Constraint | Deadline | Resources | Work | Actual work |
| --- | --- | --- | --- | --- | --- | --- | --- | --- | --- | --- | --- | --- | --- | --- | --- |
| 1 | Detail Requirements |  | 2d? | 2006-01-09 | 2006-01-10 |  |  |  | 12.5d | 3d |  |  | Tom; Lora | 16h |  |
| 2 | Review Requirements |  | 2d? | 2006-01-16 | 2006-01-17 | 1 |  |  | 9.5d | 0d | start no earlier than 2006-01-16 |  | All | 8h |  |
| 3 | Detail Requirements further |  | 2d? | 2006-01-24 | 2006-01-25 |  |  |  | 51d | 0d | start no earlier than 2006-01-24 |  | All | 8h |  |
| 4 | Review Requirements Detail |  | 2d? | 2006-01-26 | 2006-01-27 | 3 |  |  | 51d | 0d | start no earlier than 2006-01-26 |  | All | 8h |  |
| 5 | Determine process for change management |  | 2h? | 2006-01-24 | 2006-01-24 |  |  |  | 68.25d |  | start no earlier than 2006-01-24 |  | All | 2h |  |
| 6 | Determine metrics |  | 5h? | 2006-01-20 | 2006-01-23 |  |  |  | 64.7d | 53.75d | start no earlier than 2006-01-20 |  | Amanda; All | 10h |  |
| 7 | Priortize Requirements |  | 2h? | 2006-01-18 | 2006-01-18 | 2 |  |  | 9.5d | 0d | start no earlier than 2006-01-17 |  | All; Jack | 4h |  |
| 8 | Update Risks Based on Requirements |  | 2h? | 2006-01-24 | 2006-01-24 | 7 |  |  | 68.25d |  | start no earlier than 2006-01-24 |  | Amanda | 2h |  |
| 9 | Create/gather Testing templates |  | 4h? | 2006-01-24 | 2006-01-24 |  |  |  | 32d | 8d | start no earlier than 2006-01-24 |  | Amanda | 4h |  |
| 10 | Create Acceptance Test Plan |  | 6h? | 2006-01-30 | 2006-01-31 | 4 |  |  | 51d | 0d | start no earlier than 2006-01-30 |  | Shawn | 6h |  |
| 11 | Review Acceptance Test Plan |  | 3h? | 2006-01-31 | 2006-02-01 | 10 |  |  | 51d | 2.75d |  |  | All | 3h |  |
| 12 | High-level System Design |  | 4h? | 2006-01-18 | 2006-01-19 | 7 |  |  | 9.5d | 4.5d | start no earlier than 2006-01-18 |  | Nick | 4h |  |
| 13 | Review High-level System Design |  | 1h? | 2006-01-26 | 2006-01-26 | 12 |  |  | 5d | 0d | start no earlier than 2006-01-26 |  | All | 1h |  |
| 14 | Create detailed user use cases |  | 4h? | 2006-01-31 | 2006-01-31 |  |  |  | 62.25d | 1d | start no earlier than 2006-01-31 |  |  |  |  |
| 15 | Review detailed user use cases |  | 2h | 2006-02-02 | 2006-02-02 | 14 |  |  | 61.25d |  | start no earlier than 2006-02-02 |  |  |  |  |
| 16 | Create System Test Plan |  | 6h? | 2006-02-06 | 2006-02-07 | 9, 11 |  |  | 48.25d | 0d | start no earlier than 2006-02-06 |  | Shawn | 6h |  |
| 17 | Review System Test Plan |  | 3h? | 2006-02-07 | 2006-02-08 | 16 |  |  | 48.25d | 13.75d |  |  | All | 3h |  |
| 18 | Create Detailed Architecture/Application Design |  | 17h? | 2006-01-26 | 2006-02-01 | 13 |  |  | 5d | 0d |  |  | Nick | 17h |  |
| 19 | Review Detailed Architecture/Application Design |  | 4h? | 2006-02-01 | 2006-02-02 | 18 |  |  | 5d | 0d |  |  | All | 4h |  |
| 20 | Create Integration Test Plan |  | 7h? | 2006-02-16 | 2006-02-17 | 9, 24 |  |  | 14d | 0d |  |  | Shawn | 7h |  |
| 21 | Review Integration Test Plan |  | 2h? | 2006-02-17 | 2006-02-20 | 20 |  |  | 14d | 0d |  |  | All | 2h |  |
| 22 | Detailed Component Design |  | 40h? | 2006-02-02 | 2006-02-14 | 19 |  |  | 5d | 0d |  |  | Nick | 40h |  |
| 23 | MapPoint.NET Proof of concept on the server | milestone | 0h | 2006-02-17 | 2006-02-17 |  |  |  | 48.75d |  | start no earlier than 2006-02-17 |  |  |  |  |
| 24 | Reivew Detailed Component Design |  | 6h? | 2006-02-14 | 2006-02-15 | 22 |  |  | 5d | 0d |  |  | All | 6h |  |
| 25 | Create Unit Test Plan |  | 12h? | 2006-02-20 | 2006-02-23 | 24, 9, 21 |  |  | 14d | 0d |  |  | Shawn | 12h |  |
| 26 | Review Unit Test Plan |  | 3h? | 2006-02-23 | 2006-02-23 | 25 |  |  | 14d | 0d |  |  | All | 3h |  |
| 27 | Create and review all Test Plans | milestone | 0h | 2006-02-23 | 2006-02-23 | 11, 17, 21, 26 |  |  | 43.75d |  |  |  |  |  |  |
| 28 | UI Paper Prototype |  | 16h? | 2006-01-31 | 2006-02-03 |  |  |  | 59.75d | 1d | start no earlier than 2006-01-31 |  | Lora; Amanda | 32h |  |
| 29 | Sign off on UI Prototype | milestone | 0h | 2006-02-07 | 2006-02-07 | 28 |  |  | 58.75d |  | start no earlier than 2006-02-07 |  | Jack; All |  |  |
| 30 | Proof of concept with MapPoint.NET |  | 5h? | 2006-01-09 | 2006-01-10 |  |  |  | 27.5d | 0d |  |  | Shawn | 5h |  |
| 31 | Research/Set-up Nokia IDE |  | 25h? | 2006-01-10 | 2006-01-18 | 30 |  |  | 27.5d | 22.5d |  |  | All | 25h |  |
| 32 | Nokia IDE Connects to the Internet | milestone | 0h | 2006-01-18 A | 2006-01-18 A | 31 | 100% |  |  |  |  |  |  |  |  |
| 33 | Proven interaction between the IDE and GPS Hardware |  | 4h? | 2006-02-01 A | 2006-02-01 | 32 | 20% | 3.2h? | 17d | 12d | start no earlier than 2006-02-01 |  | Nick; Tom | 8h | 1.6h |
| 34 | Construct Components |  | 60h? | 2006-02-16 | 2006-03-08 | 24, 30, 31, 33 |  |  | 5d | 0d |  |  | All | 60h |  |
| 35 | Unit test each component |  | 25h? | 2006-03-09 | 2006-03-17 | 34, 26 |  |  | 5d | 0d |  |  | All | 25h |  |
| 36 | Bug Fixing (after Unit testing) |  | 20h? | 2006-03-17 | 2006-03-24 | 35 |  |  | 5d | 0d |  |  | All | 20h |  |
| 37 | Construct Components and conduct Unit tests | milestone | 0h | 2006-03-24 | 2006-03-24 | 36 |  |  | 5d | 0d |  |  |  |  |  |
| 38 | Integrate each component into system |  | 10h? | 2006-03-24 | 2006-03-28 | 37 |  |  | 5d | 0d |  |  | All | 10h |  |
| 39 | Integration Testing |  | 15h? | 2006-03-28 | 2006-04-03 | 38, 21, 36 |  |  | 5d | 0d |  |  | All | 15h |  |
| 40 | Bug Fixing (after integration testing) |  | 12h? | 2006-04-03 | 2006-04-06 | 39 |  |  | 5d | 0d |  |  | All | 12h |  |
| 41 | System test |  | 10h? | 2006-04-06 | 2006-04-10 | 17, 40 |  |  | 5d | 0d |  |  | Shawn | 10h |  |
| 42 | Bug Fixing (after System testing) |  | 10h? | 2006-04-11 | 2006-04-13 | 41 |  |  | 5d | 0d |  |  | All | 10h |  |
| 43 | Acceptance test |  | 7h? | 2006-04-13 | 2006-04-17 | 11, 42 |  |  | 5d | 0d |  |  | Jack | 7h |  |
| 44 | Bug Fixing (after Acceptance testing) |  | 10h? | 2006-04-17 | 2006-04-19 | 43 |  |  | 5d | 0d |  |  | All | 10h |  |
| 45 | Sign off on application | milestone | 0h | 2006-04-19 | 2006-04-19 | 44 |  |  | 5d |  |  |  |  |  |  |
| 46 | Put together first quarter presentation |  | 10h? | 2006-02-17 | 2006-02-21 |  |  |  | 0d |  | finish no earlier than 2006-02-21 | 2006-02-21 | Lora; All | 20h |  |
| 47 | Put together second quarter presentation |  | 20h | 2006-04-19 | 2006-04-26 | 46, 44 |  |  | 19d |  | start no earlier than 2006-04-10 | 2006-05-23 | Lora; All | 40h |  |
| 48 | Investigate SOAP and MapPoint.NET interaction |  | 10h? | 2006-01-24 | 2006-01-26 |  |  |  | 66d |  | start no earlier than 2006-01-24 |  | Shawn; Tom | 10h |  |
| 49 | Create Users Manual |  | 15h? | 2006-03-13 | 2006-03-16 |  |  |  | 29d |  | start no earlier than 2006-03-13 |  | Lora; Amanda | 30h |  |
| 50 | Determine process for compiliation |  | 2h? | 2006-01-26 | 2006-01-26 |  |  |  | 66.25d |  | start no earlier than 2006-01-26 |  | All | 2h |  |
| 51 | Compile metrics |  | 20h? | 2006-04-05 A | 2006-04-11 | 6 | 4% | 19.2h? | 10.75d |  | start no earlier than 2006-04-05 |  | Amanda; Lora | 40h | 1.6h |
| 52 | Create Technical Report |  | 15h? | 2006-04-03 | 2006-04-06 |  |  |  | 14d |  | start no earlier than 2006-04-02 |  | Amanda; Lora | 30h |  |
